# MS Project KOM Series1

Schedule from MS Project, 2008-04-14 to 2009-05-31.
Home

## Calendars

- Standard: Mon-Fri 08:00-12:00, 13:00-17:00; Sat-Sun off. Exceptions (off unless hours are given): 2008-04-20 08:00-12:00, 13:00-17:00, 2008-05-04 08:00-12:00, 13:00-17:00, 2008-05-11 08:00-12:00, 13:00-17:00, 2008-05-18 08:00-12:00, 13:00-17:00, 2008-05-24 to 2008-05-25 08:00-12:00, 13:00-17:00, 2008-05-31 to 2008-06-01 08:00-12:00, 13:00-17:00, 2009-04-19 08:00-12:00, 13:00-17:00, 2009-05-03 08:00-12:00, 13:00-17:00, 2009-05-10 08:00-12:00, 13:00-17:00, 2009-05-16 to 2009-05-17 08:00-12:00, 13:00-17:00, 2009-05-23 to 2009-05-24 08:00-12:00, 13:00-17:00, 2009-05-30 to 2009-05-31 08:00-12:00, 13:00-17:00.

## Resources

| Resource |
| --- |
| Event Team |
| MM Pfizer and EO |
| Marketing Mgr Pfizer and EO |
| Marketing Mgr Pfizer and ET |
| Pfizer and ET |
| Pfizer |
| EO and beyond blue execute memo of understanding |
| EO and beyond blue |
| Mike O'Reilly and Phil Johnston |
| Mike O'Reilly |
| Phil Johnston |
| NSW Police and Hornsby Council |
| NSW Police |
| RTA |
| National Parks and Hornsby Council |
| Karen |
| Karen B |
| EO and RTV |
| EO and RTV Producer |
| EO |
| APO and RTV Producer |
| APC and RTV Producer |
| Pfizer and EO |
| Channel 9 |
| Seven Network |
| 10 Network |
| Foxtell |
| beyond blue |
| Pfizer & 4 members of ET |
| ='9 months Time Line'!AG4 |
| APC |
| RTV Producer |
| ET |
| AMBit |
| Tissot |
| Swiss timing |
| Mike O'Reilly |
| RTA National Parks and Hornsby Council |
| Federal Department of Health and Aging |
| NSW State Health |
| RO |
| Marketing Mgr Pfizer and ET members |
| Mike |
| Mark & Karen |
| ET and beyond blue |
| BHP-B and EO |
| BHP-B and ET members |
| BHP-B and ET |
| BHP-B |
| ET and Wheelchair Sports Assoc NSW |
| ET and BHP-B |
| NSW Health |
| BHP-B & 4 members of ET |
| Wheelchair Sports Assoc NSW |
| BHP-B and and EO |
| StateLab and EO |
| StateLab and ET members |
| StateLab and ET |
| StateLab and and EO |
| StateLab |
| StateLab & 4 members of ET |
| Fed&StateLab & 4 members of ET |

## Schedule

| ID | WBS | Task | Duration | Start | Finish | Predecessors | Total slack | Free slack | Constraint | Resources | Work |
| --- | --- | --- | --- | --- | --- | --- | --- | --- | --- | --- | --- |
| 1 | 1 | Post Invitation Letter to Government which includes 3 @ CD ROMs requesting a 60 min Presentation meeting to explain the invitation. | 1d | 2008-05-18 | 2008-05-18 |  | 237d | 0d | start no earlier than 2008-05-18 | Event Team | 8h |
| 2 | 2 | EO presents to Government | 1d | 2008-05-19 | 2008-05-19 | 1 | 237d | 0d | start no earlier than 2007-07-09 | StateLab and EO | 8h |
| 3 | 3 | FedLab notifies EO it agrees to progress discussions re Invitation | 1d | 2008-05-20 | 2008-05-20 | 2 | 237d | 0d | start no earlier than 2007-07-17 | StateLab and EO | 8h |
| 4 | 4 | 2nd meeting with Government with other members of Event Team | 1d | 2008-05-21 | 2008-05-21 | 3 | 237d | 0d | start no earlier than 2007-07-25 | StateLab and ET members; Mike; Mark & Karen | 24h |
| 5 | 5 | EO and FedLab agree strategy to elicit support from all Stakeholders listed in Annexure IV | 1d | 2008-05-22 | 2008-05-22 | 4 | 237d | 0d | start no earlier than 2007-03-29 | StateLab and EO | 8h |
| 6 | 6 | FedLab agrees to be Sole Sponsor and executes Memorandum of Understanding agreeing Task Schedule and Gantt Chart and Term Sheet with ET for Inaugural KOM Series in Syd in Apr/May 08 | 1d | 2008-05-23 | 2008-05-23 | 5 | 237d | 0d | start no earlier than 2007-05-07 | StateLab and ET | 8h |
| 7 | 7 | EO drafts invitation letter for StateLab to send to Wheelchair Sports Assoc NSW inviting it to endorse KOM Series | 1d | 2008-05-24 | 2008-05-24 | 6 | 237d | 0d | start no earlier than 2007-07-25 | EO | 8h |
| 8 | 8 | EO drafts Memorandum of Understanding for Wheelchair Sports Assoc NSW to endorse KOM Series | 1d | 2008-05-25 | 2008-05-25 | 7 | 237d | 0d |  | EO | 8h |
| 9 | 9 | StateLab/ET approach Wheelchair Sports Assoc NSW and provides invitation letter to Wheelchair Sports Assoc NSW requesting it to endorse KOM Series | 1d | 2008-05-26 | 2008-05-26 | 8 | 237d | 0d | start no earlier than 2007-07-18 | StateLab and and EO | 8h |
| 10 | 10 | StateLab and ET meet with Wheelchair Sports Assoc NSW re endorsing KOM Series incl its logo appearing on all KOM Jerseys | 0.5d | 2008-05-27 | 2008-05-27 | 9 | 265d | 0d | start no earlier than 2007-04-12 | ET and Wheelchair Sports Assoc NSW; StateLab | 8h |
| 11 | 11 | StateLab and ET obtain approval in principal from Wheelchair Sports Assoc NSW to endorse KOM Series with its logo on 4 types of bicycle jerseys and promotional material | 0.5d | 2008-05-27 | 2008-05-27 | 10 | 265d | 0d | start no earlier than 2007-05-03 | ET and Wheelchair Sports Assoc NSW; StateLab | 8h |
| 12 | 12 | StateLab, ET and Wheelchair Sports Assoc execute Memo of Understanding for Wheelchair Sports logo to appear on cycle jerseys and associated promotional material | 1d | 2008-05-28 | 2008-05-28 | 11 | 271d | 0d | start no earlier than 2007-05-07 | StateLab; ET and Wheelchair Sports Assoc NSW | 16h |
| 13 | 13 | Open discussions with NSW Police and local council for approval to use 3 KOM Climbs | 1d | 2008-07-07 | 2008-07-07 |  | 241d | 0d | start no earlier than 2008-07-07 | Mike O'Reilly; Phil Johnston; NSW Police; RTA; National Parks and Hornsby Council | 40h |
| 14 | 14 | Event Team obtains consent in principal from Police and Local Council to use 3 KOM Climbs for Individual Time Trials over 6 consecutive w'ends from mid-Oct | 1d | 2008-07-08 | 2008-07-08 | 13 | 241d | 0d | start no earlier than 2007-04-26 | Mike O'Reilly; Phil Johnston; NSW Police; RTA; National Parks and Hornsby Council | 40h |
| 15 | 15 | Event Team obtains written consent from all required agencies to use 3 KOM Climbs for Individual Time Trials over 6 consecutive w'ends from mid-Oct | 1d | 2008-07-09 | 2008-07-09 | 14 | 241d |  | start no earlier than 2007-05-16 | Phil Johnston; NSW Police; RTA National Parks and Hornsby Council; Mike O'Reilly | 32h |
| 16 | 16 | StateLab, EO and Wheelchair Sports Assoc NSW approach Australian Paralympic Committee to co-ordinate involvement of elite Disabled Australian athletes in Disabled Categories of KOM Challenge | 1d | 2008-05-28 | 2008-05-28 | 11 | 265d | 0d | start no earlier than 2007-04-16 | StateLab; EO | 16h |
| 17 | 17 | StateLab and ET meet with APC to discuss APC administering involvement of elite Disabled Australian athletes in KOM | 2d | 2008-05-29 | 2008-05-30 | 16 | 265d | 0d | start no earlier than 2007-05-07 | StateLab; ET | 32h |
| 18 | 18 | StateLab, ET and APC execute Memo of Understanding for APC to administer involvement of elite Disabled Australian athletes in KOM | 2d | 2008-05-31 | 2008-06-01 | 17 | 265d | 0d | start no earlier than 2007-04-27 | ET; StateLab | 32h |
| 19 | 19 | APC commence approaching elite Disabled athletes to compete in KOM Series | 1d? | 2008-06-02 | 2008-06-02 | 18 | 28d | 0d |  |  |  |
| 20 | 20 | APC provides to RTV Producer a short list of 50 elite Disabled athletes to compete in KOM Series | 3d | 2008-06-03 | 2008-06-05 | 19 | 265d |  | start no earlier than 2007-06-05 | APC; RTV Producer | 48h |
| 21 | 21 | Event Team begins testing electronic Climb Time measurement equipment AMBit ChipX Decoder, Tissot and Swiss Timing | 5d | 2008-04-14 | 2008-04-18 |  | 304d | 0d | start no earlier than 2008-04-14 | ET; AMBit; Tissot; Swiss timing | 160h |
| 22 | 22 | Event Team selects between AMBit, Tissot and Swiss Timing to be purchased by Event Organiser | 2d | 2008-04-20 | 2008-04-21 | 21 | 304d | 0d | finish no earlier than 2007-04-27 | ET; AMBit; Tissot; Swiss timing | 64h |
| 23 | 23 | Test software to publish performance reports to www.KOMpm.com | 1d | 2008-04-22 | 2008-04-22 | 22 | 304d |  | start no earlier than 2007-05-02 | ET; AMBit; Tissot; Swiss timing | 32h |
| 24 | 24 | EO drafts letters to Federal Department of Health and Aging and NSW State Health seeking its support for Inaugural KOM Series | 1d | 2008-05-26 | 2008-05-26 | 8 | 271d | 0d | start no earlier than 2007-03-15 | EO | 8h |
| 25 | 25 | StateLab, EO jointly write to Federal Department of Health and Aging seeking its support for Inaugural KOM Series | 1d | 2008-05-27 | 2008-05-27 | 24 | 272d | 0d |  | StateLab; EO | 16h |
| 26 | 26 | StateLab and Event Team meet with Federal Department of Health and Aging seeking its support for KOM Series | 1d | 2008-05-28 | 2008-05-28 | 25 | 272d | 0d | start no earlier than 2007-04-18 | StateLab; EO; Federal Department of Health and Aging | 24h |
| 27 | 27 | StateLab and Event Organiser obtain letter of support from Federal Dept of Health & Aging to support KOM Series | 1d? | 2008-05-29 | 2008-05-29 | 26 | 272d |  | start no earlier than 2007-05-11 | EO; StateLab | 16h |
| 28 | 28 | StateLab and Event Organiser conjointly write to NSW State Health seeking its support for KOM Series | 1d? | 2008-05-27 | 2008-05-27 | 24 | 271d | 0d |  | StateLab; EO | 16h |
| 29 | 29 | StateLab and Event Team meet with NSW State Health seeking its support for KOM Series | 1d | 2008-05-28 | 2008-05-28 | 28 | 271d | 0d | start no earlier than 2007-05-03 | NSW Health; EO; StateLab | 24h |
| 30 | 30 | StateLab and Event Organiser obtain letter of support from NSW State Health to support KOM Series | 1d? | 2008-05-29 | 2008-05-29 | 29 | 271d | 0d | start no earlier than 2007-05-10 | StateLab; EO | 16h |
| 31 | 31 | Published Invitation to KOM Series on www.KOMpm.com with provision for Competitor personal profiles | 1d? | 2008-05-30 | 2008-05-30 | 30 | 271d |  |  | StateLab and EO | 8h |
| 32 | 32 | StateLab and EO approach 4 Free to Air and Cable Television Networks re Reality Television episodes | 2d | 2008-05-28 | 2008-05-29 | 11 | 269.67d | 0d | finish no earlier than 2007-04-06 | StateLab & 4 members of ET | 16h |
| 33 | 33 | StateLab and Event Organiser to meet with Television Networks re Reality Television episodes | 0.67d | 2008-05-30 | 2008-05-30 | 32 | 269.67d | 0d |  | StateLab; EO; Channel 9; Seven Network; 10 Network; Foxtell | 32h |
| 34 | 34 | APC provides to RTV Producer a short list of 50 elite Disabled athletes to compete in KOM Series | 3d? | 2008-05-31 | 2008-06-02 | 17 | 268d |  | start no earlier than 2007-05-21 | APC and RTV Producer | 24h |
| 35 | 35 | EO provides TV RTV Producer shortlist of 20 Abled Competitor Profiles | 1d | 2008-05-30 | 2008-05-31 | 33 | 269.67d | 0d | start no earlier than 2007-05-31 | StateLab; EO and RTV Producer | 16h |
| 36 | 36 | StateLab, EO and APC lock-in a Television Network to produce 4 episodes of Reality Television | 0.67d? | 2008-05-31 | 2008-06-01 | 35 | 269.67d |  | start no earlier than 2007-06-06 | StateLab; EO; APC and RTV Producer | 16h |
| 37 | 37 | EO drafts a letter, and postal addresses, for Wheelchair Sports Assoc NSW to write to Aust Sports Commission, Aust Bicycle Council, Cycling NSW, Cycling Aust, BFA, BNSW | 2d | 2008-05-27 | 2008-05-28 | 9 | 237d | 0d |  | EO | 16h |
| 38 | 38 | Wheelchair Sports Assoc NSW writes to Aust Sports Commission, NSW Bicycle Organisations ie Aust Bicycle Council, Cycling NSW, Cycling Australia, BFA, BNSW notifying it endorses KOM Series and seeking support | 1d? | 2008-05-29 | 2008-05-29 | 37 | 237d | 0d |  | Wheelchair Sports Assoc NSW | 8h |
| 39 | 39 | StateLab and EO jointly write to Cycling NSW, Cycling Aust, BFA ,BNSW referring to Wheelchair Sports Assoc NSW recent letter, and seek their support | 1d? | 2008-05-30 | 2008-05-30 | 38 | 237d | 0d |  | StateLab and EO | 8h |
| 40 | 40 | EO prepares a letter & merge document for StateLab-B and EO to send to 80 bicycle shops seeking support for KOM Series to attract new members to cycling and assist disable enhance their QOL, with all phone and e-mail enquiries to Phil/Karen | 1d? | 2008-05-28 | 2008-05-28 | 11 | 271d | 0d |  | EO | 8h |
| 41 | 41 | StateLab and EO send letter to 80 bicycle shops seeking support for KOM Series to attract new members to cycling and assist disable enhance their QOL, with all phone and e-mail enquiries to Phil/Karen | 1d? | 2008-05-29 | 2008-05-29 | 40 | 271d | 0d | start no earlier than 2007-04-26 | StateLab and EO | 8h |
| 42 | 42 | Event Team (Phil & Karen) commence receiving phone calls and e-mails from bicycle shops expressing interest in supporting KOM Series | 1d? | 2008-05-30 | 2008-05-30 | 41 | 271d |  |  | EO; Karen | 16h |
| 43 | 43 | EO drafts a letter merge document for StateLab and EO to write to 40 Bicycle Racing Clubs and 20 Bicycle User Groups within 50km of a KOM Climb seeking their support, with all enquiries to Phil/Karen | 1d? | 2008-05-31 | 2008-05-31 | 39 | 269d | 0d |  | EO | 8h |
| 44 | 44 | StateLab and EO write to 40 Bicycle Racing Clubs and 20 Bicycle User Groups within 50km of a KOM Climb seeking their support, with all enquiries to Phil/Karen | 1d? | 2008-06-01 | 2008-06-01 | 43 | 269d |  |  | StateLab and EO | 8h |
| 45 | 45 | EO drafts a letter for Wheelchair Sports Assoc NSW to write to 30 Registered Charities for the Disabled notifying it endorses KOM Series | 1d | 2008-05-31 | 2008-05-31 | 39 | 237d | 0d |  | EO | 8h |
| 46 | 46 | EO provides draft letter and merge document for Wheelchair Sport Assoc NSW write to 30 Registered Charities for the Disabled | 1d? | 2008-06-01 | 2008-06-01 | 45 | 237d | 0d |  | EO; Wheelchair Sports Assoc NSW | 16h |
| 47 | 47 | Wheelchair Sport Assoc NSW writes to 30 Charities for Disabled notifying it endorese KOM Series and seeking their support | 1d? | 2008-06-02 | 2008-06-02 | 46 | 237d | 0d |  | EO; Wheelchair Sports Assoc NSW | 16h |
| 48 | 48 | StateLab and EO conjointly write to 30 Charities, referring to Wheelchair Sport Assoc NSW's letter, and asks for the charity's support for Disabled Category Finals day | 1d? | 2008-06-03 | 2008-06-03 | 47 | 237d | 0d |  | StateLab; EO | 16h |
| 49 | 49 | ET (Phil & Karen) commence phoning and e-mailing 30 charities seeking charity to contact Karen/Phil if interested in KOM Series | 30d | 2008-06-04 | 2008-07-15 | 48 | 237d |  |  | ET | 240h |
| 50 | 50 | EO drafts letter and merge document for Wheelchair Sports Assoc NSW to write to Top 100 CEOs, Senior Partner of Law and Accounting Practices, Heads of Govt Depts inviting their employees to consider KOM Series for both Abled and Disabled employees | 1d? | 2008-07-07 | 2008-07-07 | 53 | 243d |  | start no earlier than 2008-07-07 | EO | 8h |
| 51 | 51 | Wheelchair Sports Assoc NSW writes to Top 100 CEOs, Senior Partner of Law and Accounting Practices, Heads of Govt Depts inviting their employees to consider KOM Series for both Abled and Disabled employees | 1d? | 2008-05-31 | 2008-05-31 | 17 | 269d | 0d |  | Wheelchair Sports Assoc NSW | 8h |
| 52 | 52 | ET (Phil & Karen) commence receiving phone calls and e-mails from employees from Top 200 companies expressing interest in KOM Series | 1d? | 2008-06-01 | 2008-06-01 | 51 | 269d |  |  | EO; Karen | 16h |
| 53 | 53 | EO prepares a letter & merge document for StateLab and EO to send to 20 local councils seeking support for KOM Series to attract new members to cycling and assist disable enhance their QOL | 1d? | 2008-07-04 | 2008-07-04 |  | 242d | 0d | start no earlier than 2008-07-04 | EO | 8h |
| 54 | 54 | StateLab-B and Event Organiser write to 20 Local Councils within 50km of a KOM Climb, seeking support KOM Series which will attract new members to cycling and assist disable enhance their QOL, with all phone and e-mail enquiries to Phil/Karen | 1d? | 2008-07-07 | 2008-07-07 | 53 | 242d | 0d |  | EO; StateLab | 16h |
| 55 | 55 | StateLab-B and EO write to 20 Local Councils within 50km of a KOM Climb, seeking support KOM Series which will attract new members to cycling and assist disable enhance their QOL, with all phone and e-mail enquiries to Phil/Karen | 1d? | 2008-07-08 | 2008-07-08 | 54 | 242d |  |  | EO; StateLab | 16h |
| 56 | 56 | EO drafts letter, prepares a merge for StateLab and EO to write to 20 Bicycle Suppliers and 3 Tour Company within 50km of a KOM Climb seeking support KOM Series, with all enquiries to Phil/Karen | 1d? | 2008-07-07 | 2008-07-07 | 53 | 242d | 0d |  | EO | 8h |
| 57 | 57 | StateLab and EO write to 20 Bicycle Suppliers and 3 Tour Company within 50km of a KOM Climb seeking support KOM Series, with all phone and e-mail enquiries to Phil/Karen | 1d? | 2008-07-08 | 2008-07-08 | 56 | 242d |  |  | EO; StateLab | 16h |
| 58 | 58 | ET e-mails Cycling Forums seeking support for KOM Series which will attract new members to cycling and assist disable enhance their QOL | 1d? | 2008-05-01 | 2008-05-01 |  | 297d |  | start no earlier than 2008-05-01 | EO | 8h |
| 59 | 59 | Agree style and supplier of 4 types of StateLab-B jerseys and Winner medallions | 2d | 2008-05-29 | 2008-05-30 | 12 | 34d |  |  |  |  |
| 60 | 60 | Publishing individual Climber Profile Pages and Climber Photo on www.KOMpm.com for each of 400 Climbers in Semi-Finals and 100 Climbers in Disabled Finals | 1d? | 2008-05-01 | 2008-05-01 |  | 60d |  | start no earlier than 2008-05-01 |  |  |
| 65 | 61 | 1st Semi Final - M & F 18>25, 25<30 - 80 Climbers | 1d | 2009-04-19 | 2009-04-19 |  | 35d | 10d | start no earlier than 2009-04-19 | Fed&StateLab & 4 members of ET | 8h |
| 66 | 62 | 1st Semi Final - M & F 18>25, 25<30 - 80 Climbers | 1d | 2009-05-03 | 2009-05-03 | 65 | 25d | 5d | start no earlier than 2009-05-03 | Fed&StateLab & 4 members of ET | 8h |
| 67 | 63 | 2nd Semi Final - M & F 30>35, 35<40 - 80 Climbers | 1d | 2009-05-10 | 2009-05-10 | 66 | 20d | 5d | start no earlier than 2009-05-10 | Fed&StateLab & 4 members of ET | 8h |
| 68 | 64 | 3rd Semi Final - M & F 40>45, 45<50 - 80 Climbers | 1d | 2009-05-16 | 2009-05-16 | 67 | 15d |  | start no earlier than 2009-05-16 | Fed&StateLab & 4 members of ET | 8h |
| 69 | 65 | 4th Semi Final - M & F 50<55, 55<60 - 80 Climbers | 1d | 2009-05-17 | 2009-05-17 |  | 14d |  | start no earlier than 2009-05-17 | Fed&StateLab & 4 members of ET | 8h |
| 70 | 66 | Disabled Final - 5 Categories across 2 Sexes - 100 Climbers | 1d | 2009-05-23 | 2009-05-23 |  | 8d |  | start no earlier than 2009-05-23 | Fed&StateLab & 4 members of ET | 8h |
| 71 | 67 | 5th Semi Final and Extras - 60<65, >65 Males, >60 Females - 60 + Extras | 1d | 2009-05-24 | 2009-05-24 |  | 5d |  | start no earlier than 2009-05-24 | Fed&StateLab & 4 members of ET | 8h |
| 72 | 68 | 1st Finals Day - M & F 18>25, 25<30, 30>35, 35<40, 40>45 - 50 Climbers | 1d | 2009-05-30 | 2009-05-30 | 71 | 0d |  | start no earlier than 2009-05-30 | Fed&StateLab & 4 members of ET | 8h |
| 73 | 69 | 2nd Finals Day - M & F 45<50, 50>55, 55<60, 60>65, >65 - 45 Climbers | 1d | 2009-05-31 | 2009-05-31 | 72 | 0d |  | start no earlier than 2009-05-31 | Fed&StateLab & 4 members of ET | 8h |
